# CRONOGRAMA TESIS PLAN DE GESTION DE MANTENIMIENTO

Schedule from MS Project, 2024-01-09 to 2024-02-28, costs in $.

## Calendars

- CALENDARIO LABORAL 2024: Mon-Fri 06:00-11:00, 13:00-16:00; Sat-Sun off.

## Schedule

| ID | WBS | Task | Type | Duration | Start | Finish | Predecessors | Total slack | Free slack | Constraint | Cost |
| --- | --- | --- | --- | --- | --- | --- | --- | --- | --- | --- | --- |
| 1 | 1 | **INICIO DEL PROYECTO** |  | 10d | 2024-01-09 | 2024-01-22 |  | 0d |  |  | 18,360,514.44 |
| 2 | 1.1 | Estudios Tecnicos |  | 10d | 2024-01-09 | 2024-01-22 |  | 0d |  |  | 15,000,000 |
| 3 | 1.2 | Reunion programacion de los trabajos | milestone | 0d | 2024-01-22 | 2024-01-22 | 2 | 0d |  |  | 3,360,514.44 |
| 4 | 2 | **1. PRELIMINARES** |  | 8d | 2024-01-23 | 2024-02-01 | 3 | 0d |  |  | 4,059,167.5 |
| 5 | 2.1 | 1.1 Rocería y desmonte manual |  | 5d | 2024-01-23 | 2024-01-29 | 3 | 1.38d | 0d |  | 1,834,027.5 |
| 6 | 2.2 | 1.2 Recolección y retiro de basuras y desechos |  | 2d | 2024-01-30 | 2024-01-31 | 5 | 1.38d |  |  | 101,195 |
| 7 | 2.3 | 1.3 Remoción de señales irregulares y otros elementos invasores |  | 3d | 2024-01-29 | 2024-01-31 | 5FS-1d | 1.38d |  |  | 139,876 |
| 8 | 2.4 | 1.4 Limpieza de pavimento asfaltico, rígido o sistema de placa huella |  | 8d | 2024-01-23 | 2024-02-01 | 3 | 0d |  |  | 1,844,193 |
| 9 | 2.5 | 1.5 Retiro de Obstáculos |  | 3d | 2024-01-23 | 2024-01-25 |  | 5.38d |  |  | 139,876 |
| 10 | 3 | **2. MANTENIMIENTO DE OBRAS DE CONTENCIÓN** |  | 9d | 2024-02-02 | 2024-02-14 |  | 10d |  |  | 509,104.5 |
| 11 | 3.1 | 2.1 Despedrado de taludes |  | 7d | 2024-02-02 | 2024-02-12 | 4 | 16.38d | 0d |  | 102,754.5 |
| 12 | 3.2 | 2.2 Limpieza de muro |  | 5d | 2024-02-08 | 2024-02-14 | 11FS-3d | 16.38d |  |  | 406,350 |
| 13 | 4 | **3. MANTENIMIENTO DE PÁVIMENTOS ASFALTICOS** |  | 17d | 2024-02-02 | 2024-02-26 |  | 0d |  |  | 1,044,630.91 |
| 14 | 4.1 | 3.1 Sellado de grietas en calzada y bermas |  | 10d | 2024-02-02 | 2024-02-15 | 4 | 0d |  |  | 285,836.42 |
| 15 | 4.2 | 3.2 Parcheo en calzada y bermas pavimentadas |  | 13d | 2024-02-08 | 2024-02-26 | 14FS-6d | 2d | 0d |  | 495,149.34 |
| 16 | 4.3 | 3.3 Bacheo de pavimentos asfálticos |  | 10d | 2024-02-13 | 2024-02-26 | 15SS+3d | 2d |  |  | 263,645.15 |
| 17 | 5 | **4. MANTENIMIENTO DE PAVIMENTOS RIGIDOS** |  | 10d | 2024-02-08 | 2024-02-21 |  | 5d |  |  | 42,290 |
| 18 | 5.1 | 4.1 Sellado de grietas en calzada y bermas |  | 10d | 2024-02-08 | 2024-02-21 | 14SS+4d | 5d |  |  | 42,290 |
| 19 | 6 | **5. MANTENIMIENTO DE OBRAS DE DRENAJE** |  | 17d | 2024-02-06 | 2024-02-28 |  | 0d |  |  | 641,779.58 |
| 20 | 6.1 | 5.1 Limpieza de canales y zanjas de coronación |  | 15d | 2024-02-06 | 2024-02-26 | 8FS+2d | 8.38d |  |  | 590,929.58 |
| 21 | 6.2 | 5.2 Sellado de juntas y grietas en cunetas, bajantes de agua y zanjas de coronación de concreto |  | 15d | 2024-02-08 | 2024-02-28 | 14SS+4d | 0d |  |  | 50,850 |
| 22 | 7 | **6. MANTENIMIENTO DE SEÑALIZACIÓN** |  | 18d | 2024-02-02 | 2024-02-27 |  | 1d |  |  | 5,656,623.52 |
| 23 | 7.1 | 6.1 Limpieza de señales verticales |  | 8d | 2024-02-02 | 2024-02-13 | 4 | 1d | 0d |  | 3,395.52 |
| 24 | 7.2 | 6.2 Reemplazo de señales verticales laterales |  | 7d | 2024-02-19 | 2024-02-27 | 23FS+3d | 1d |  |  | 5,653,228 |
| 25 | 8 | Cierre | milestone | 0d | 2024-02-28 | 2024-02-28 |  | 0.62d |  | start no earlier than 2024-02-28 |  |
